# AUP QA Schedule

Schedule from MS Project, 2019-06-21 to 2019-07-19.
Brookhaven National Laboratory

## Calendars

- Standard: Mon-Fri 08:00-12:00, 13:00-17:00; Sat-Sun off.

## Resources

| Resource |
| --- |
| 1 |
| Instru-Dep |
| SD |
| DS |
| New EE Tech |
| HS |
| MM |
| PK |
| MA |
| JM |
| PJ |
| ALL |
| JP |

## Schedule

| ID | Task | Type | Duration | Start | Finish | Predecessors | Total slack | Free slack | Resources | Work |
| --- | --- | --- | --- | --- | --- | --- | --- | --- | --- | --- |
| 1 | PXIe 4300 cards, order submitted |  | 1d? | 2019-06-21 | 2019-06-21 |  | 20d |  | SD | 8h |
| 2 | Prepare for empty PCB board assemby, parts list, specs (Maxim) |  | 3d | 2019-06-21 | 2019-06-25 |  | 0d |  | HS; SD; MM | 72h |
| 3 | Submit Order of electronci parts |  | 1d | 2019-06-26 | 2019-06-26 | 2 | 0d |  | SD | 8h |
| 4 | Modeling of quench antenna (existing), dimentional check, PCB |  | 4d | 2019-06-21 | 2019-06-26 |  | 8d | 0d | PK; MA; DS; HS | 128h |
| 5 | Drawing of quench antenna, vs coil poisiton |  | 1d | 2019-06-27 | 2019-06-27 | 4 | 8d | 0d | PK; MA | 16h |
| 6 | Modeling of modified quench antenna |  | 3d | 2019-06-28 | 2019-07-02 | 5 | 8d | 0d | PK; MA | 48h |
| 7 | Spacer drawing, PCB modification for N2 tube? |  | 2d | 2019-07-03 | 2019-07-04 | 6 | 8d | 0d | PK | 16h |
| 8 | New spacers to be made (16 mm length) |  | 3d | 2019-07-05 | 2019-07-09 | 7 | 8d |  | SD | 24h |
| 9 | Electronic parts delivered at BNL |  | 1d? | 2019-06-27 | 2019-06-27 | 3 | 0d |  | HS | 8h |
| 10 | Empty PCB board assembly |  | 4d | 2019-06-28 | 2019-07-03 | 9 | 0d |  | Instru-Dep; HS | 64h |
| 11 | Completion of 1st thermal cycle - AP1b | manual | 1d | 2019-06-26 | 2019-06-26 |  |  |  | JM | 8h |
| 12 | Quench antenna re-engineering |  | 4d | 2019-06-27 | 2019-07-02 | 11 | 13d |  | SD; DS; PJ | 96h |
| 13 | Assembly of modified antenna |  | 4d | 2019-07-04 | 2019-07-09 | 10 | 0d |  | SD; DS | 64h |
| 14 | Underground cable from QA to NI Chassis (PXIe 4300 cards) |  | 4d | 2019-07-10 | 2019-07-15 | 13 | 0d |  | SD; DS; New EE Tech | 96h |
| 15 | Completion of modified QA assemby |  | 1d | 2019-07-16 | 2019-07-16 | 14 | 0d |  | ALL | 8h |
| 16 | Testing of modified QA |  | 3d | 2019-07-17 | 2019-07-19 | 15 | 0d |  | SD; HS; DS; JP | 96h |
